# 3GPP_Release-2000

Schedule from MS Project, 1999-01-01 to 2017-06-14, A marks actual dates.

| ID | WBS | Task | Duration | Start | Finish | Complete | Baseline start | Baseline finish | Baseline duration | Constraint | Resources | Work | Actual work | Release | MCC resp | Acronym | Acronym_3GU_Export |
| --- | --- | --- | --- | --- | --- | --- | --- | --- | --- | --- | --- | --- | --- | --- | --- | --- | --- |
| 4880 | 1145 | **Call Forwarding** | 261d? | 1999-01-01 A | 1999-12-31 A | 100% | 1999-01-01 | 1999-12-31 | 261d? |  | SMG1; N2; N4 | 16704h | 16704h | R99 | Kimmo |  |  |
| 4881 | 1145.1 | Call Forwarding enhancements | 261d? | 1999-01-01 A | 1999-12-31 A | 100% | 1999-01-01 | 1999-12-31 | 261d? | start no earlier than 1999-01-01 | N4; N2 | 4176h | 4176h | R99 | Kimmo | CF_enhancements | CF_enhancements |
| 4882 | 1145.2 | Call_Forwarding | 261d? | 1999-01-01 A | 1999-12-31 A | 100% | 1999-01-01 | 1999-12-31 | 261d? | start no earlier than 1999-01-01 | SMG1; N2 | 4176h | 4176h | R99 | Kimmo | Call_Forwarding | Call_Forwarding |
| 4883 | 1145.3 | Call_Forwarding_Enhancements | 261d? | 1999-01-01 A | 1999-12-31 A | 100% | 1999-01-01 | 1999-12-31 | 261d? | start no earlier than 1999-01-01 | N4 | 2088h | 2088h | R99 | Kimmo | Call_Forwarding_Enhancements | Call_Forwarding_Enhancements |
| 4884 | 1146 | **Quality of Service** | 261d? | 1999-01-01 A | 1999-12-31 A | 100% | 1999-01-01 | 1999-12-31 | 261d? |  | S2; T2; N1; N2; N4 | 31320h | 31320h | R99 | Maurice |  |  |
| 4885 | 1146.1 | End-to-end UMTS Quality of Service management | 261d? | 1999-01-01 A | 1999-12-31 A | 100% | 1999-01-01 | 1999-12-31 | 261d? | start no earlier than 1999-01-01 | S2; T2; N1; N2; N4 | 10440h | 10440h | R99 | Maurice | QoS | QoS |
| 4886 | 1146.2 | End-to-end QoS for PS Domain including IMS | 261d? | 1999-01-01 A | 1999-12-31 A | 100% | 1999-01-01 | 1999-12-31 | 261d? | start no earlier than 1999-01-01 | S2 | 2088h | 2088h | R99 | Maurice | E2EQoS99 | E2EQoS |
| 4887 | 1146.3 | GPRS-enhanced_QoS | 261d? | 1999-01-01 A | 1999-12-31 A | 100% | 1999-01-01 | 1999-12-31 | 261d? | start no earlier than 1999-01-01 | T2 | 2088h | 2088h | R99 |  | GPRS-enhanced_QoS | GPRS-enhanced_QoS |
| 4888 | 1146.4 | QoS_enhancements | 261d? | 1999-01-01 A | 1999-12-31 A | 100% | 1999-01-01 | 1999-12-31 | 261d? | start no earlier than 1999-01-01 | N2; N1; N4 | 6264h | 6264h | R99 | Kimmo | QoS_enhancements | QoS_enhancements |
| 4889 | 1147 | Support of Localised Service Area | 261d? | 1999-01-01 A | 1999-12-31 A | 100% | 1999-01-01 | 1999-12-31 | 261d? | start no earlier than 1999-01-01 | SMG2; SMG3; SMG7; N2 | 8352h | 8352h | R99 | Maurice | SoLSA | SoLSA |
| 4890 | 1148 | Transcoder_location | 261d? | 1999-01-01 A | 1999-12-31 A | 100% | 1999-01-01 | 1999-12-31 | 261d? | start no earlier than 1999-01-01 | S2 | 2088h | 2088h | R99 | Maurice | Transcoder_location | Transcoder_location |
| 4891 | 1149 | Antenna_test_methods | 261d? | 1999-01-01 A | 1999-12-31 A | 100% | 1999-01-01 | 1999-12-31 | 261d? | start no earlier than 1999-01-01 | SMG2 | 2088h | 2088h | R99 |  | Antenna_test_methods | Antenna_test_methods |
| 4892 | 1150 | WBAMR / high quality speech in UMTS Phase 1 but not in R99 | 261d? | 1999-01-01 A | 1999-12-31 A | 100% | 1999-01-01 | 1999-12-31 | 261d? | start no earlier than 1999-01-01 | S1 | 2088h | 2088h | R99 | Alain | WBAMR | WBAMR |
| 4893 | 1151 | **Codec** | 261d? | 1999-01-01 A | 1999-12-31 A | 100% | 1999-01-01 | 1999-12-31 | 261d? |  | S4 | 27144h | 27144h | R99 | Paolo |  |  |
| 4894 | 1151.1 | **Codecs for Multimedia Telephony Service** | 261d? | 1999-01-01 A | 1999-12-31 A | 100% | 1999-01-01 | 1999-12-31 | 261d? |  | S4 | 14616h | 14616h | R99 | Paolo | Codec_for_Multimedia_Telephony | Codec_for_Multimedia_Telephony |
| 4895 | 1151.1.1 | Codecs for Multimedia Telephony Service | 261d? | 1999-01-01 A | 1999-12-31 A | 100% | 1999-01-01 | 1999-12-31 | 261d? | start no earlier than 1999-01-01 | S4 | 2088h | 2088h | R99 | Paolo | Multimedia_Codec | Multimedia_Codec |
| 4896 | 1151.1.2 | Codecs for Multimedia Telephony Service | 261d? | 1999-01-01 A | 1999-12-31 A | 100% | 1999-01-01 | 1999-12-31 | 261d? | start no earlier than 1999-01-01 | S4 | 2088h | 2088h | R99 | Paolo | CSM | CSM |
| 4897 | 1151.1.3 | Codecs for Multimedia Telephony Service | 261d? | 1999-01-01 A | 1999-12-31 A | 100% | 1999-01-01 | 1999-12-31 | 261d? | start no earlier than 1999-01-01 | S4 | 2088h | 2088h | R99 | Paolo | WI2MMC | WI2MMC |
| 4898 | 1151.1.4 | Codecs for Multimedia Telephony Service | 261d? | 1999-01-01 A | 1999-12-31 A | 100% | 1999-01-01 | 1999-12-31 | 261d? | start no earlier than 1999-01-01 | S4 | 2088h | 2088h | R99 | Paolo | Codec(s)_for_CS_MM_Tel._Serv | Codec(s)_for_CS_MM_Tel._Serv |
| 4899 | 1151.1.5 | Codecs for Multimedia Telephony Service | 261d? | 1999-01-01 A | 1999-12-31 A | 100% | 1999-01-01 | 1999-12-31 | 261d? | start no earlier than 1999-01-01 | S4 | 2088h | 2088h | R99 | Paolo | Codec(s)_for_MM_Tel_Service | Codec(s)_for_MM_Tel_Service |
| 4900 | 1151.1.6 | Codecs for Multimedia Telephony Service | 261d? | 1999-01-01 A | 1999-12-31 A | 100% | 1999-01-01 | 1999-12-31 | 261d? | start no earlier than 1999-01-01 | S4 | 2088h | 2088h | R99 | Paolo |  |  |
| 4901 | 1151.2 | QoS for Speech and Multimedia Codec | 261d? | 1999-01-01 A | 1999-12-31 A | 100% | 1999-01-01 | 1999-12-31 | 261d? | start no earlier than 1999-01-01 | S4 | 2088h | 2088h | R99 | Paolo | QoS_for_Speech_&_MM_Codecs_/_AMR | QoS_for_Speech_&_MM_Codecs_/_AMR |
| 4902 | 1151.3 | Tandem Free Operation - Adaptive Multi-Rate codec types | 261d? | 1999-01-01 A | 1999-12-31 A | 100% | 1999-01-01 | 1999-12-31 | 261d? | start no earlier than 1999-01-01 | S4 | 2088h | 2088h | R99 | Paolo | TFOAMR | TFOAMR |
| 4903 | 1151.4 | Noise Suppression for AMR | 261d? | 1999-01-01 A | 1999-12-31 A | 100% | 1999-01-01 | 1999-12-31 | 261d? | start no earlier than 1999-01-01 | S4 | 2088h | 2088h | R99 | Paolo | AMRNS | AMRNS |
| 4904 | 1151.5 | Out-of-Band Transcoder | 261d? | 1999-01-01 A | 1999-12-31 A | 100% | 1999-01-01 | 1999-12-31 | 261d? | start no earlier than 1999-01-01 | N1 | 2088h | 2088h | R99 | Frederic | OoBT | OoBT |
| 4905 | 1151.6 | Out-of-Band Transcoder Control | 261d? | 1999-01-01 A | 1999-12-31 A | 100% | 1999-01-01 | 1999-12-31 | 261d? | start no earlier than 1999-01-01 | N1 | 2088h | 2088h | R99 | Frederic | OoBTC | OoBTC |
| 4906 | 1152 | Advanced Speech Call Items enhancements | 261d? | 1999-01-01 A | 1999-12-31 A | 100% | 1999-01-01 | 1999-12-31 | 261d? | start no earlier than 1999-01-01 | SMG1; SMG2; SMG3; SMG7; SMG9; N1; N4; S1; T2 | 18792h | 18792h | R99 | Alain | ASCI | ASCI |
| 4907 | 1153 | Call Control improvements | 261d? | 1999-01-01 A | 1999-12-31 A | 100% | 1999-01-01 | 1999-12-31 | 261d? | start no earlier than 1999-01-01 | N1 | 2088h | 2088h | R99 | Frederic | CC_Related_items | CC_Related_items |
| 4908 | 1154 | Multimedia | 261d? | 1999-01-01 A | 1999-12-31 A | 100% | 1999-01-01 | 1999-12-31 | 261d? | start no earlier than 1999-01-01 | N1; N3 | 4176h | 4176h | R99 | Frederic | Multimedia | Multimedia |
| 4909 | 1155 | Sub-System Number allocation for RANAP, RNSAP | 261d? | 1999-01-01 A | 1999-12-31 A | 100% | 1999-01-01 | 1999-12-31 | 261d? | start no earlier than 1999-01-01 | N2 | 2088h | 2088h | R99 | Frederic | SSN_allocation | SSN_allocation |
| 4910 | 1156 | Intranet / ISP access with DHCP end-to-end | 261d? | 1999-01-01 A | 1999-12-31 A | 100% | 1999-01-01 | 1999-12-31 | 261d? | start no earlier than 1999-01-01 | N3 | 2088h | 2088h | R99 | Gwiho | ISPaccess | ISPaccess |
| 4911 | 1157 | Point_to_Multipoint_Services | 261d? | 1999-01-01 A | 1999-12-31 A | 100% | 1999-01-01 | 1999-12-31 | 261d? | start no earlier than 1999-01-01 | N3 | 2088h | 2088h | R99 | Gwiho | Point_to_Multipoint_Services | Point_to_Multipoint_Services |
| 4912 | 1158 | Facsimile | 261d? | 1999-01-01 A | 1999-12-31 A | 100% | 1999-01-01 | 1999-12-31 | 261d? | start no earlier than 1999-01-01 | S1 | 2088h | 2088h | R99 | Alain | FAX | FAX |
| 4913 | 1159 | Realtime_NT_FAX_in_UMTS | 261d? | 1999-01-01 A | 1999-12-31 A | 100% | 1999-01-01 | 1999-12-31 | 261d? | start no earlier than 1999-01-01 | N3 | 2088h | 2088h | R99 | Gwiho | Realtime_NT_FAX_in_UMTS | Realtime_NT_FAX_in_UMTS |
| 4914 | 1160 | Gateway Location Register (GLR) - Mobile Application Part (MAP) specification | 261d? | 1999-01-01 A | 1999-12-31 A | 100% | 1999-01-01 | 1999-12-31 | 261d? | start no earlier than 1999-01-01 | N4 | 2088h | 2088h | R99 | Kimmo | GLR | GLR |
| 4915 | 1161 | Multiple Subscriber Profile phase 2 | 261d? | 1999-01-01 A | 1999-12-31 A | 100% | 1999-01-01 | 1999-12-31 | 261d? | start no earlier than 1999-01-01 | S1; N4 | 4176h | 4176h | R99 | Alain | MSP2 | MSP2 |
| 4916 | 1162 | Prepaging | 261d? | 1999-01-01 A | 1999-12-31 A | 100% | 1999-01-01 | 1999-12-31 | 261d? | start no earlier than 1999-01-01 | N2; N4 | 4176h | 4176h | R99 | Kimmo | Prepaging | Prepaging |
| 4917 | 1163 | Re-definition of channel quality measure used for AMR link adaptation for Downlink Advanced Receiver Performance (DARP) MS | 261d? | 1999-01-01 A | 1999-12-31 A | 100% | 1999-01-01 | 1999-12-31 | 261d? | start no earlier than 1999-01-01 | SMG | 2088h | 2088h | R99 |  |  |  |
| 4918 | 1164 | Harmonized Standard | 261d? | 1999-01-01 A | 1999-12-31 A | 100% | 1999-01-01 | 1999-12-31 | 261d? | start no earlier than 1999-01-01 | SMG2 | 2088h | 2088h | R99 |  | HS | HS |
| 4919 | 1165 | Streamlining of specifications | 261d? | 1999-01-01 A | 1999-12-31 A | 100% | 1999-01-01 | 1999-12-31 | 261d? | start no earlier than 1999-01-01 | N3 | 2088h | 2088h | R99 | Gwiho | Streamlining | Streamlining |
| 4920 | 1166 | R99_Service_Clean_up | 261d? | 1999-01-01 A | 1999-12-31 A | 100% | 1999-01-01 | 1999-12-31 | 261d? | start no earlier than 1999-01-01 | N3 | 2088h | 2088h | R99 | Gwiho | R99_Service_Clean_up | R99_Service_Clean_up |

Notes:
- 4880: -
- 4881: No additional features for R99. / Impacted TSs and TRs: 23.078, 23.079, 23.082, 29.002, 29.078
- 4882: - / Impacted TSs and TRs: 02.82, 29.002
- 4883: - / Impacted TSs and TRs: 23.082
- 4884: WID SMG 98-0781 End To End UMTS QoS Management
- 4885: WID SMG 98-0781 End To End UMTS QoS Management / Impacted TSs and TRs: 23.107, 23.907, 24.008
- 4886: Acronym changed from E2EQos / Impacted TSs and TRs: 23.060, 23.170
- 4887: AT-commands for Enhanced QoS Support management / Impacted TSs and TRs: 27.007
- 4888: - / Impacted TSs and TRs: 23.008, 23.016, 24.008, 29.002, 29.060
- 4889: Mechanism which can be used as a platform for providing special tariffs and/or special set of service features for certain subscribers within a regionally restricted area or areas. No additional features for R99. / Impacted TSs and TRs: 04.08, 04.18, 08.08, 11.10-1, 29.002
- 4890: UE location identification: background information and associated primitives 2. Transcoder location at the core network and source depending coding belonging to the non-access stratum. / Impacted TSs and TRs: 23.110
- 4891: - / Impacted TSs and TRs: 03.30
- 4892: Add requirement for high quality speech in UMTS Phase 1 but not in R99 / Impacted TSs and TRs: 22.105
- 4893: -
- 4894: -
- 4895: - / Impacted TSs and TRs: 26.911, 26.104, 26.111
- 4896: - / Impacted TSs and TRs: 26.911, 26.104, 26.111
- 4897: - / Impacted TSs and TRs: 26.911, 26.104, 26.111
- 4898: - / Impacted TSs and TRs: 26.911, 26.104, 26.111
- 4899: - / Impacted TSs and TRs: 26.911, 26.104, 26.111
- 4900: - / Impacted TSs and TRs: 26.911, 26.104, 26.111
- 4901: - / Impacted TSs and TRs: 26.102, 26.912
- 4902: UMTS_AMR2 is default Codec Type in R99 dual_mode terminals / Impacted TSs and TRs: 26.103
- 4903: Combination of the AMR speech codec and the Noise Suppression function. TS 06.77 and TR 06.78 only apply to GSM. They apply to UMTS from Rel-4 onwards, when they were converted to TS 26.077 and TR 26.078. / Impacted TSs and TRs: 06.77, 06.78
- 4904: Transcoder handling in the CN at inter-system handover and relocation + Introduction of UMTS AMR / Impacted TSs and TRs: 23.009, 24.008
- 4905: 24.008 CR#0572 in NP-020220 was approved under this WI / Impacted TSs and TRs: 24.008 CR#0572 in NP-020220
- 4906: - / Impacted TSs and TRs: 02.30, 02.68, 03.68, 03.69, 04.18, 08.08, 11.10-1, 11.11, 23.067, 23.094, 24.008, 24.067, 27.007, 29.002
- 4907: Minor improvements to 24.007 and 24.008 to increase the number of simultaneous calls/sessions from the present 7: the TI value is increased (NP-99441). / Impacted TSs and TRs: 24.007, 24.008
- 4908: - / Impacted TSs and TRs: 24.008, 27.001, 29.007
- 4909: Sub-System Number allocation for Radio Access Network Application Part, Radio Network Subsystem Application Part / Impacted TSs and TRs: 23.003
- 4910: Access to an Intranet/ISP with DHCP end to end / Impacted TSs and TRs: 29.061
- 4911: Support for the IP-Multicast protocol / Impacted TSs and TRs: 29.061
- 4912: - / Impacted TSs and TRs: 22.003, 22.100
- 4913: Asynchronous Interface for real-time NT Fax + Introduction of Asynchronous interface for Real-time non-transparent FAX / Impacted TSs and TRs: 27.001, 27.003
- 4914: - / Impacted TSs and TRs: 29.120
- 4915: - / Impacted TSs and TRs: 22.097, 23.072, 23.083, 23.084, 23.091, 23.093, 23.097
- 4916: - / Impacted TSs and TRs: 23.018, 23.082, 29.002
- 4917: Re-definition of channel quality measure used for AMR link adaptation for DARP MS / Impacted TSs and TRs: 05.09
- 4918: - / Impacted TSs and TRs: 13.21
- 4919: - / Impacted TSs and TRs: 27.060, 29.061
- 4920: - / Impacted TSs and TRs: 03.10, 27.001, 27.002, 27.003, 27.060, 29.007, 29.061

| ID | WBS | Task | Type | Duration | Start | Finish | Complete | Baseline start | Baseline finish | Baseline duration | Constraint | Resources | Work | Actual work | Acronym | Release | MCC resp | Acronym_3GU_Export | Impacted TSs and TRs | TSG stopped | WI rapporteur name | WI rapporteur e-mail |
| --- | --- | --- | --- | --- | --- | --- | --- | --- | --- | --- | --- | --- | --- | --- | --- | --- | --- | --- | --- | --- | --- | --- |
| 4921 | 1167 | **(Small) Technical Enhancements and Improvements for R99** |  | 261d? | 1999-01-01 A | 1999-12-31 A | 100% | 1999-01-01 | 1999-12-31 | 261d? |  | N3 | 6264h | 6264h | TEI | R99 | Gwiho | TEI |  |  |  |  |
| 4922 | 1167.1 | TEI_[CS_Data] |  | 261d? | 1999-01-01 A | 1999-12-31 A | 100% | 1999-01-01 | 1999-12-31 | 261d? | start no earlier than 1999-01-01 | N3 | 2088h | 2088h | TEI_[CS_Data] | R99 | Gwiho | TEI_[CS_Data] |  |  |  |  |
| 4923 | 1167.2 | TEI_[GPRS] |  | 261d? | 1999-01-01 A | 1999-12-31 A | 100% | 1999-01-01 | 1999-12-31 | 261d? | start no earlier than 1999-01-01 | N3 | 2088h | 2088h | TEI_[GPRS] | R99 | Gwiho | TEI_[GPRS] |  |  |  |  |
| 4924 | 1168 | **R99 UE Conformance Testing** |  | 261d? | 1999-01-01 A | 1999-12-31 A | 100% | 1999-01-01 | 1999-12-31 | 261d? |  | R5; T1 | 6264h | 6264h | TEI_Test | R99 | Ingbert | TEI_Test | 34.108, 34.121, 34.122, 34.123-1, 34.123-2, 34.123-3 |  |  |  |
| 4925 | 1168.1 | Deleted - RTEI |  | 261d? | 1999-01-01 A | 1999-12-31 A | 100% | 1999-01-01 | 1999-12-31 | 261d? | start no earlier than 1999-01-01 | T1 | 2088h | 2088h | RTEI | R99 | Ingbert | RTEI | 34.123-1 CR#0650, 0651, 34.123-3 CR#0148, 0149, 0150 | TP-06 |  |  |
| 4926 | 1168.2 | Common test environments for User Equipment (UE); Conformance testing | milestone | 0d? | 1999-01-01 A | 1999-01-01 A | 100% | 1999-01-01 | 1999-01-01 | 0d? | start no earlier than 1999-01-01 | R5; T1 |  |  |  | R99 | Ingbert |  | 34.108 |  |  |  |
| 4927 | 1168.3 | Terminal conformance specification, Radio transmission and reception (FDD) | milestone | 0d? | 1999-01-01 A | 1999-01-01 A | 100% | 1999-01-01 | 1999-01-01 | 0d? | start no earlier than 1999-01-01 | R5; T1 |  |  |  | R99 | Ingbert |  | 34.121 |  |  |  |
| 4928 | 1168.4 | Terminal conformance specification, Radio transmission and reception (TDD) | milestone | 0d? | 1999-01-01 A | 1999-01-01 A | 100% | 1999-01-01 | 1999-01-01 | 0d? | start no earlier than 1999-01-01 | R5; T1 |  |  |  | R99 | Ingbert |  | 34.122 |  |  |  |
| 4929 | 1168.5 | UE conformance specification; Part 1: Protocol conformance specification | milestone | 0d? | 1999-01-01 A | 1999-01-01 A | 100% | 1999-01-01 | 1999-01-01 | 0d? | start no earlier than 1999-01-01 | R5; T1 |  |  |  | R99 | Ingbert |  | 34.123-1 |  |  |  |
| 4930 | 1168.6 | UE conformance specification; Part 2: Implementation Conformance Statement (ICS) specification | milestone | 0d? | 1999-01-01 A | 1999-01-01 A | 100% | 1999-01-01 | 1999-01-01 | 0d? | start no earlier than 1999-01-01 | R5; T1 |  |  |  | R99 | Ingbert |  | 34.123-2 |  |  |  |
| 4931 | 1168.7 | UE conformance specification; Part 3: Abstract test suites (ATSs) | milestone | 0d? | 1999-01-01 A | 1999-01-01 A | 100% | 1999-01-01 | 1999-01-01 | 0d? | start no earlier than 1999-01-01 | R5; T1 |  |  |  | R99 | Ingbert |  | 34.123-3 |  |  |  |
| 4932 | 1169 | Deleted - Dual Tone Multi-Frequency signalling : Support in the whole 3GPP system |  | 261d? | 1999-01-01 A | 1999-12-31 A | 100% | 1999-01-01 | 1999-12-31 | 261d? | start no earlier than 1999-01-01 | N1 | 2088h | 2088h | DTMF | R99 | Frederic | DTMF | 23.014 CR#0004 | NP-06 |  |  |
| 4933 | 1170 | Deleted - Intersystem_Change |  | 261d? | 1999-01-01 A | 1999-12-31 A | 100% | 1999-01-01 | 1999-12-31 | 261d? | start no earlier than 1999-01-01 | SMG | 2088h | 2088h | Intersystem_Change | R99 |  | Intersystem_Change | 04.18 CR#A243 | SMG |  |  |
| 4934 | 1171 | Deleted - Long_Forwardedto_Numbers |  | 261d? | 1999-01-01 A | 1999-12-31 A | 100% | 1999-01-01 | 1999-12-31 | 261d? | start no earlier than 1999-01-01 | N2 | 2088h | 2088h | Long_Forwardedto_Numbers | R99 | Kimmo | Long_Forwardedto_Numbers | 29.002 | NP-06 |  |  |
| 4935 | 1172 | Deleted - RANimp-FSEarlyUE |  | 261d? | 1999-01-01 A | 1999-12-31 A | 100% | 1999-01-01 | 1999-12-31 | 261d? | start no earlier than 1999-01-01 | R3 | 2088h | 2088h | RANimp-FSEarlyUE | R99 | Juha | RANimp-FSEarlyUE | 25.413 CR#0520, 0538, 0565, 0563, 0541, 0540, 0539, 0547 | RP-06 |  |  |
| 4936 | 1173 | Release 1999 Studies |  | 261d? | 1999-01-01 A | 1999-12-31 A | 100% | 1999-01-01 | 1999-12-31 | 261d? |  | S1; T2 | 4176h | 4176h |  | R99 | Alain |  |  |  |  |  |
| 4937 | 1174 | Advanced Addressing/Numbering |  | 261d? | 1999-01-01 A | 1999-12-31 A | 100% | 1999-01-01 | 1999-12-31 | 261d? | start no earlier than 1999-01-01 | S1 | 2088h | 2088h | Numbering | R99 | Alain | Numbering | 22.975 |  | Vodafone | mona.mustapha@vodafone.com |
| 4938 | 1175 | Combined GSM and Mobile IP mobility handling in UMTS IP CN |  | 261d? | 1999-01-01 A | 1999-12-31 A | 100% | 1999-01-01 | 1999-12-31 | 261d? | start no earlier than 1999-01-01 | S2 | 2088h | 2088h |  | R99 | Maurice |  | 23.923 |  |  |  |
| 4939 | 1176 | UE Capabilities Requirements |  | 261d? | 1999-01-01 A | 1999-12-31 A | 100% | 1999-01-01 | 1999-12-31 | 261d? | start no earlier than 1999-01-01 | T2 | 2088h | 2088h | UCR | R99 |  | UCR | 21.904 |  |  |  |
| 4940 | 1177 | Electrical safety requirements and regulations |  | 261d? | 1999-01-01 A | 1999-12-31 A | 100% | 1999-01-01 | 1999-12-31 | 261d? | start no earlier than 1999-01-01 | T2 | 2088h | 2088h |  | R99 |  |  | 34.907 |  |  |  |
| 4941 | 1178 | Specific Absorbtion Rate (SAR) requirements and regulations in different regions |  | 261d? | 1999-01-01 A | 1999-12-31 A | 100% | 1999-01-01 | 1999-12-31 | 261d? | start no earlier than 1999-01-01 | T2 | 2088h | 2088h |  | R99 |  |  | 34.925 |  |  |  |
| 4942 | 1179 | Multi-mode UE issues |  | 261d? | 1999-01-01 A | 1999-12-31 A | 100% | 1999-01-01 | 1999-12-31 | 261d? | start no earlier than 1999-01-01 | T2 | 2088h | 2088h |  | R99 |  |  | 21.810, 21.910 |  |  |  |
| 4943 | 1180 | Provision of fax service in GSM and UMTS |  | 261d? | 1999-01-01 A | 1999-12-31 A | 100% | 1999-01-01 | 1999-12-31 | 261d? | start no earlier than 1999-01-01 | T2 | 2088h | 2088h |  | R99 |  |  | 22.945 |  | Ericsson | peter.bleckert@ericsson.com |
| 4944 | 1181 | Separating Radio Resources and Mobility Management specific parts of the MS Classmark |  | 261d | 1999-01-01 A | 1999-12-31 A | 100% | 1999-01-01 | 1999-12-31 | 261d |  | T2 | 2088h | 2088h |  | R99 |  |  | 23.814 |  |  |  |

Notes:
- 4921: -
- 4922: -
- 4923: -
- 4924: Specifies Conformance Tests for a 3G UE to be recognised as 3GPP-standard compliant. A 3GPP-external body, GCF (Global Certification Forum), delivers certificates to prove that a UE has correctly passed tests and is then conform to the 3GPP standard.
- 4925: No CR or new TS/TR approved under this WI
- 4926: -
- 4927: measurement procedures for the conformance test of the UE that contain transmitting characteristics, receiving characteristics and performance requirements in addition to requirements for support of RRM (Radio Resource Management) in FDD mode.
- 4928: measurement procedures for the conformance test of the UE that contain transmitting characteristics, receiving characteristics and performance requirements in addition to requirements for support of RRM (Radio Resource Management) in TDD mode.
- 4929: TS 34.123, composed of three parts, actually specifies the protocol conformance testing for the 3G UE. Part 1 describes the overall test structure.
- 4930: Part 2 contains the applicability of each test case defined as the Implementation Conformance Statement (ICS) proforma, in compliance with the relevant requirements, and in accordance with the relevant guidance given in ISO/IEC 9646-7 and ETS 300 406.
- 4931: Part 3 specifies the protocol conformance testing in TTCN for the 3G UE at the Uu interface. It defines the TTCN test specification and design considerations in Abstract Test Suites based on the test cases specified in prose in part 1.
- 4932: No CR or new TS/TR approved under this WI
- 4933: No CR or new TS/TR approved under this WI
- 4934: -
- 4935: No CR or new TS/TR approved under this WI
- 4936: -
- 4937: Study on requirements for numbering and addressing for UMTS
- 4938: -
- 4939: Moved to CT1 at TSG-T closure
- 4940: Moved to RAN4 at TSG-T closure. TR summarizes differences between international and national standards relevant to IEC60950 and refers to regulations for conformity assessment due to different regulatory environments in different countries / regions.
- 4941: Moved to RAN4 at TSG-T closure.
- 4942: Moved to CT1 at TSG-T closure. Consequences on roaming capabilities and service availability (e.g. handover) of multi-mode UEs while roaming in various regions with various network configurations. Case studies for each of the possible scenarios in specs
- 4943: CP#27: Moved to C1 on closure of T2; see TP-050062. CP#28: C1->C3
- 4944: CP#27: change of WG as a result of closure of CN and T.
